Schedule from MS Project, 2025-05-16 to 2026-12-01, costs in S.

## Calendars

- Estándar: Mon-Sun 07:00-12:00.

## Resources

| Resource | Group | Rate | Cost per use |
| --- | --- | --- | --- |
| CAPATAZ | Mano de Obra | 38.3 |  |
| OPERARIO | Mano de Obra | 29.99 |  |
| OFICIAL | Mano de Obra | 23.6 |  |
| PEON | Mano de Obra | 21.36 |  |
| PEON - VIGIA | Mano de Obra | 21.36 |  |
| PEON - VIGIA | Mano de Obra | 21.36 |  |
| TOPOGRAFO | Mano de Obra | 31.09 |  |
| MATERIAL PROPIO DE LAS EXCAVACIONES | Material |  | 21.44 |
| ALQUILER DE OFICINA ADMINISTRATIVA EN OBRA | Material |  | 7500 |
| ALAMBRE NEGRO N° 16 | Material |  | 4.35 |
| ALAMBRE NEGRO #8 | Material |  | 6.35 |
| ACERO CORRUGADO fy = 4200 kg/cm2 GRADO 60 | Material |  | 4.03 |
| ACERO CORRUGADO fy = 4200 kg/cm2 GRADO 60 DE 3/8" X 9 m | Material |  | 25.81 |
| SERVICIO DE TELEFONIA | Material |  | 537.5 |
| CLAVOS DIFERENTES MEDIDAS | Material |  | 6.37 |
| ARENA GRUESA | Material |  | 38.45 |
| MATERIALES PARA SEÑALIZACION Y SEGURIDAD VIAL | Material |  | 6591 |
| GEOTEXTIL NO TEJIDO DE 400 GR/CM2 | Material |  | 8.39 |
| TUBERIA HDPE DN 800mm | Material |  | 1285 |
| CEMENTO PORTLAND TIPO I (42.5 kg) | Material |  | 28.89 |
| YESO BOLSA 28 kg | Material |  | 19.77 |
| CONCRETO PREMEZCLADO F'C=100 kg/cm2 CON CEMENTO T-V | Material |  | 522.89 |
| CONCRETO PREMEZCLADO F'C=280 kg/cm2 CON CEMENTO T-V | Material |  | 716.22 |
| SERVICIO DE INTERNET | Material |  | 1075 |
| SERVICIO DE AGUA Y DESAGUE | Material |  | 537.5 |
| DESMOLDADOR PARA ENCOFRADO | Material |  | 105.46 |
| MADERA TORNILLO | Material |  | 6.04 |
| ESTACAS DE MADERA | Material |  | 6.04 |
| PINTURA ESMALTE | Material |  | 38.45 |
| ELABORACION IMPLEMENTACION Y ADMINITRACION DEL PLAN DE SEGURIDAD Y SALUD EN EL TRABAJO | Material |  | 16400 |
| EQUIPO DE PREVENCION DE FATIGA SOMNOLENCIA | Material |  | 195950 |
| EQUIPO DE PROTECCION COLECTIVA | Material |  | 13182 |
| CARPA COMEDOR (CAMPO) | Material |  | 2746.25 |
| CHARLAS DE INDUCCION | Material |  | 55 |
| CAPACITACION EN SEGURIDAD Y SALUD | Material |  | 8800 |
| ALMACEN PROVISIONAL | Material |  | 4394 |
| EPPS PERSONAL INDIRECTO | Material |  | 472.36 |
| EPPS PERSONAL DIRECTO | Material |  | 1428.05 |
| RECURSOS PARA RESPUESTAS ANTE EMERGENCIAS DE SEGURIDAD Y SALUD EN EL TRABAJO | Material |  | 26364 |
| CONTENEDOR DE OFICINAS | Material |  | 714.03 |
| EXAMEN MEDICO-INGRESO | Material |  | 307.58 |
| EXAMEN MEDICO-SALIDA | Material |  | 307.58 |
| CERCO PERIMETRICO DE OBRA | Material |  | 109.85 |
| SC MONTAJE DE OFICINAS Y CONTENEDORES | Material |  | 21500 |
| SC DESMONTAJE DE OFICINAS Y CONTENEDORES | Material |  | 21500 |
| SC MOVILIZACION DE EQUIPOS | Material |  | 500573 |
| SC DESMOVILIZACION DE EQUIPOS | Material |  | 443573 |
| MATERIALES (VARIOS) | Material |  |  |
| GPS | Equipo | 16.13 |  |
| BAÑOS PORTATILES | Equipo | 1397.5 |  |
| HERRAMIENTAS MANUALES | Equipo | 8 |  |
| TRACTOR SOBRE ORUGAS CAT D8T | Equipo | 559.43 |  |
| MOTOBOMBA 8" (34HP) | Equipo | 100.5 |  |
| CAMION VOLQUETE 22M3 | Equipo | 236.98 |  |
| CARGADOR FRONTAL CAT 966-H | Equipo | 368.61 |  |
| VIBRADORA DE CONCRETO 4HP 1.50" | Equipo | 16.58 |  |
| MOBILIARIO PARA OFICINAS DE OBRA | Equipo | 64500 |  |
| COMPACTADORA VIBRATORIA TIPO PLANCHA 7 HP | Equipo | 47.92 |  |
| RODILLO LISO VIBRATORIO MANUAL 10.8 HP 0.8-1.1 Ton | Equipo | 79.45 |  |
| EXCAVADORA CAT 336 | Equipo | 412.46 |  |
| RETROEXCAVADORA SOBRE LLANTAS 94 HP 1.25 Y3 | Equipo | 188.74 |  |
| EXCAVADORA CAT 336 | Equipo | 414.78 |  |
| TRACTOR DE ORUGAS DE 190-240 HP | Equipo | 450 |  |
| TRACTOR DE ORUGAS CAT D6D | Equipo | 392.13 |  |
| TRACTOR SOBRE ORUGAS CAT D6D | Equipo | 392.13 |  |
| RODILLO LISO VIBRATORIO AUTOPROPULSADO 101-135HP 10-12TN | Equipo | 209.15 |  |
| MOTONIVELADORA 140K | Equipo | 300.53 |  |
| CAMION CISTERNA 5 000 GLN | Equipo | 210.43 |  |
| MOTONIVELADORA 130 - 135 HP | Equipo | 1 |  |
| CAMION VOLQUETE DE 15 m3 | Equipo | 187.83 |  |
| CAMION GRUA 20 TON | Equipo | 230.7 |  |
| GRUPO ELECTROGENO DE 50 KW. | Equipo | 74.14 |  |
| LAVAMANOS PORTATILES | Equipo | 645 |  |
| SEÑALIZACION TEMPORAL DE SEGURIDAD | Subcontrato |  | 6450 |

## Schedule

| ID | WBS | Task | Type | Duration | Start | Finish | Predecessors | Total slack | Constraint | Resources | Work | Cost | Text1 | Text8 | Text2 | Text3 | Text4 | Text6 |
| --- | --- | --- | --- | --- | --- | --- | --- | --- | --- | --- | --- | --- | --- | --- | --- | --- | --- | --- |
| 1 | 1 | **DEFENZAS RIBEREÑAS** |  | 57.5d | 2025-07-01 | 2025-09-29 |  |  |  |  | 7351.94h | 1,410,687.52 | 01 | 000000000000108 |  |  |  |  |
| 2 | 1.1 | **OBRAS PRELIMINARES** |  | 14d | 2025-05-17 | 2025-06-09 |  | 0d |  |  | 450.65h | 149,991.79 | 01.01 | 000000000000109 |  |  |  |  |
| 3 | 1.1.1 | INSTALACION PROVISIONAL PARA LA OBRA | manual | 5d | 2025-05-17 | 2025-05-25 | 6 |  | as late as possible | SC MONTAJE DE OFICINAS Y CONTENEDORES [50%]; SC DESMONTAJE DE OFICINAS Y CONTENEDORES [50%]; MOBILIARIO PARA OFICINAS DE OBRA [0.1%]; GRUPO ELECTROGENO DE 50 KW. [198.8%]; CERCO PERIMETRICO DE OBRA [15000%]; ALQUILER DE OFICINA ADMINISTRATIVA EN OBRA [325%]; SERVICIO DE TELEFONIA [325%]; SERVICIO DE INTERNET [325%]; SERVICIO DE AGUA Y DESAGUE [325%]; CARPA COMEDOR (CAMPO) [325%]; ALMACEN PROVISIONAL [325%]; CONTENEDOR DE OFICINAS [325%] | 79.56h | 102,659.78 | 01.01.01 | 000000000000113 | 0.5 | 454707.39 | 227353.7 | 0.0059 |
| 4 | 1.1.2 | MANTENIMIENTO DE TRANSITO Y SEGURIDAD VIAL | manual | 10d | 2025-05-24 | 2025-06-09 | 3 |  | as late as possible | OFICIAL [97.7%]; PEON - VIGIA [195.3%]; RODILLO LISO VIBRATORIO AUTOPROPULSADO 101-135HP 10-12TN [24.4%]; MOTONIVELADORA 140K [48.8%]; CAMION CISTERNA 5 000 GLN [97.7%]; MATERIALES PARA SEÑALIZACION Y SEGURIDAD VIAL [150%] | 371.09h | 47,332.01 | 01.01.02 | 000000000000111 | 1.5 | 106860.19 | 160290.29 | 0.0384 |
| 5 | 1.2 | **TRABAJO PRELIMINARES** |  | 41d | 2025-05-16 | 2025-07-20 |  | 0d |  |  | 2508h | 533,328.75 | 01.02 | 000000000000114 |  |  |  |  |
| 6 | 1.2.1 | MOVILIZACION Y DESMOVILIZACION DE EQUIPOS | manual | 1d | 2025-05-16 | 2025-05-17 |  |  | as late as possible | SC MOVILIZACION DE EQUIPOS [50%]; SC DESMOVILIZACION DE EQUIPOS [50%] | 8h | 472,073.38 | 01.02.01 | 000000000000115 | 0.5 | 944146.76 | 472073.38 |  |
| 7 | 1.2.2 | TOPOGRAFIA Y GEOREFERENCIACION | manual | 40d | 2025-05-17 | 2025-07-20 | 6 |  | as late as possible | CEMENTO PORTLAND TIPO I (42.5 kg) [450%]; YESO BOLSA 28 kg [450%]; PINTURA ESMALTE [600%]; GPS [195.3%]; PEON [293%]; TOPOGRAFO [293%]; ESTACAS DE MADERA [22500%]; ACERO CORRUGADO fy = 4200 kg/cm2 GRADO 60 DE 3/8" X 9 m [750%] | 2500h | 61,255.37 | 01.02.02 | 000000000000116 | 1.5 | 41820.35 | 62730.53 | 0.0384 |
| 8 | 1.3 | **DESCOLMATACION DE CAUCE Y OBRAS AUXILIARES** |  | 10d | 2025-05-20 | 2025-06-05 |  | 0d |  |  | 296.77h | 60,218.48 | 01.03 | 000000000000202 |  |  |  |  |
| 9 | 1.3.1 | DESBROCE Y LIMPIEZA EN ZONA NO BOSCOSA | manual | 3d | 2025-05-20 | 2025-05-25 | 7SS+2d |  | as late as possible | CAPATAZ [14.1%]; OPERARIO [75.2%]; PEON [75.2%]; PEON - VIGIA [43.1%]; TRACTOR SOBRE ORUGAS CAT D8T [20.7%]; CAMION VOLQUETE 22M3 [209.8%]; EXCAVADORA CAT 336 [3.3%]; EXCAVADORA CAT 336 [37.6%]; TRACTOR SOBRE ORUGAS CAT D6D [75.2%]; CAMION VOLQUETE DE 15 m3 [131.1%] | 164.45h | 33,040.44 | 01.03.01 | 000000000000203 | 11277.03 | 2.93 | 33041.7 | 5000 |
| 10 | 1.3.2 | DESCOLMATACION DE CAUCE NATURAL DEL RIO LACRAMARCA | manual | 2d | 2025-05-25 | 2025-05-28 | 9 |  | as late as possible | CAPATAZ [8.7%]; PEON [180.9%]; TRACTOR SOBRE ORUGAS CAT D8T [89.9%] | 44.7h | 8,716.79 | 01.03.02 | 000000000000204 | 1732.75 | 5.04 | 8733.06 | 960 |
| 11 | 1.3.3 | CONFORMACION DE DESVIO EN CAUCE DE RIO | manual | 5d | 2025-05-28 | 2025-06-05 | 10 |  | as late as possible | CAPATAZ [21.9%]; PEON [87.6%]; EXCAVADORA CAT 336 [21.9%]; TRACTOR SOBRE ORUGAS CAT D6D [87.6%] | 87.62h | 18,461.25 | 01.03.03 | 000000000000205 | 2368.03 | 7.81 | 18494.31 | 540 |
| 12 | 1.4 | **DIQUES DE TIERRA COMPACTADA CON ENROCADO** |  | 47d | 2025-05-16 | 2025-07-30 |  | 0d |  |  | 4091.02h | 666,267.74 | 01.04 | 000000000000117 |  |  |  |  |
| 13 | 1.4.1 | **DIQUE DE TIERRA COMPACTADA A1-D-01** |  | 47d | 2025-05-16 | 2025-07-30 |  | 0d |  |  | 2403.79h | 393,791.55 | 01.04.01 | 000000000000206 |  |  |  |  |
| 14 | 1.4.1.1 | EXCAVACION EN TERRENO NATURAL CON EQUIPO | manual | 24d | 2025-06-21 | 2025-07-30 | 11FS+10d |  | as late as possible | CAPATAZ [48.4%]; PEON [96.8%]; EXCAVADORA CAT 336 [114.4%]; TRACTOR DE ORUGAS CAT D6D [48.4%] | 591.54h | 135,122.99 | 01.04.01.01 | 000000000000207 | 18590.35 | 7.27 | 135151.84 | 800 |
| 15 | 1.4.1.2 | EXCAVACION DE UÑA CON EQUIPO | manual | 3d | 2025-07-20 | 2025-07-25 | 7 |  | as late as possible | CAPATAZ [15.3%]; PEON [75.7%]; MOTOBOMBA 8" (34HP) [75.7%]; EXCAVADORA CAT 336 [85%] | 60.39h | 10,811.54 | 01.04.01.02 | 000000000000208 | 1226.9 | 8.82 | 10821.26 | 540 |
| 16 | 1.4.1.3 | PERFILADO Y COMPACTACION EN ZONA DE CORTE | manual | 10d | 2025-05-16 | 2025-06-01 |  |  | as late as possible | CAPATAZ [18.3%]; PEON [91.6%]; EXCAVADORA CAT 336 [46.2%] | 124.91h | 17,450.75 | 01.04.01.03 | 000000000000209 | 5864.1 | 2.99 | 17533.66 | 640 |
| 17 | 1.4.1.4 | PEDRAPLEN e=60 cm | manual | 3d | 2025-05-16 | 2025-05-20 |  |  | as late as possible | CAPATAZ [18.3%]; OFICIAL [90.4%]; PEON [90.4%]; EXCAVADORA CAT 336 [8.9%]; TRACTOR DE ORUGAS CAT D6D [90.4%] | 71.64h | 10,536.77 | 01.04.01.04 | 000000000000210 | 1517.8 | 6.97 | 10579.07 | 560 |
| 18 | 1.4.1.5 | PEDRAPLEN e=30 cm | manual | 2d | 2025-05-16 | 2025-05-19 |  |  | as late as possible | CAPATAZ [16.1%]; OFICIAL [81.3%]; PEON [81.3%]; EXCAVADORA CAT 336 [8.3%]; TRACTOR DE ORUGAS CAT D6D [81.3%] | 42.93h | 6,334.82 | 01.04.01.05 | 000000000000211 | 779.1 | 8.17 | 6365.25 | 480 |
| 19 | 1.4.1.6 | CONFORMACION DE CUERPO DE DIQUE CON MATERIAL DE PRESTAMO | manual | 8d | 2025-05-16 | 2025-05-28 |  |  | as late as possible | CAPATAZ [17.6%]; OFICIAL [88.9%]; PEON [101.8%]; TRACTOR SOBRE ORUGAS CAT D6D [88.9%]; RODILLO LISO VIBRATORIO AUTOPROPULSADO 101-135HP 10-12TN [88.9%]; MOTONIVELADORA 140K [44.5%]; CAMION CISTERNA 5 000 GLN [51.6%] | 308.65h | 52,889.57 | 01.04.01.06 | 000000000000213 | 3126.8 | 16.95 | 52999.26 | 440 |
| 20 | 1.4.1.7 | CONFORMACION DE MATERIAL GRANULAR EN CORONA DE DIQUE | manual | 2d | 2025-05-16 | 2025-05-19 |  |  | as late as possible | CAPATAZ [15.3%]; OFICIAL [76.1%]; PEON [82.2%]; RODILLO LISO VIBRATORIO AUTOPROPULSADO 101-135HP 10-12TN [76.1%]; MOTONIVELADORA 140K [76.1%]; CAMION CISTERNA 5 000 GLN [24.2%] | 56.01h | 7,684.25 | 01.04.01.07 | 000000000000214 | 365.8 | 21.06 | 7703.75 | 240 |
| 21 | 1.4.1.8 | GEOTEXTIL NO TEJIDO 400 G/M2, INC. COLOCACION | manual | 8d | 2025-05-16 | 2025-05-28 |  |  | as late as possible | CAPATAZ [17.4%]; OFICIAL [178.3%]; PEON [714.5%]; CAMION GRUA 20 TON [26.8%]; GEOTEXTIL NO TEJIDO DE 400 GR/CM2 [960861%] | 599.68h | 97,461.87 | 01.04.01.08 | 000000000000215 | 8579.12 | 11.88 | 101919.95 | 1200 |
| 22 | 1.4.1.9 | COLOCACION Y ACOMODO DE ROCA EN UÑA DE DIQUE | manual | 4d | 2025-05-16 | 2025-05-22 |  |  | as late as possible | CAPATAZ [49.1%]; OFICIAL [98.2%]; PEON [491.8%]; EXCAVADORA CAT 336 [98.2%]; TRACTOR SOBRE ORUGAS CAT D6D [24.6%] | 243.8h | 20,821.02 | 01.04.01.09 | 000000000000216 | 1227.6 | 17.07 | 20955.13 | 312 |
| 23 | 1.4.1.10 | COLOCACION Y ACOMODO DE ROCA EN TALUD DE DIQUE | manual | 4d | 2025-05-16 | 2025-05-22 |  |  | as late as possible | CAPATAZ [45.1%]; OFICIAL [89.9%]; PEON [539.6%]; EXCAVADORA CAT 336 [179.8%]; TRACTOR SOBRE ORUGAS CAT D6D [22.4%] | 280.58h | 31,596.04 | 01.04.01.10 | 000000000000217 | 805.8 | 39.4 | 31748.52 | 224 |
| 24 | 1.4.1.11 | CONFORMACION DE RELLENO NO ESTRUCTURAL CON MATERIAL PROPIO | manual | 1d | 2025-05-16 | 2025-05-17 |  |  | as late as possible | CAPATAZ [42.6%]; OFICIAL [84.4%]; PEON [84.4%]; TRACTOR SOBRE ORUGAS CAT D6D [84.4%] | 23.67h | 3,081.94 | 01.04.01.11 | 000000000000218 | 710.75 | 4.35 | 3091.76 | 840 |

| ID | WBS | Task | Type | Duration | Start | Finish | Total slack | Constraint | Resources | Work | Cost | Text1 | Text8 | Text2 | Text3 | Text4 | Text6 |
| --- | --- | --- | --- | --- | --- | --- | --- | --- | --- | --- | --- | --- | --- | --- | --- | --- | --- |
| 25 | 1.4.2 | **DIQUE DE TIERRA COMPACTADA A1-I-01** |  | 4d | 2025-05-16 | 2025-05-22 | 0d |  |  | 456.65h | 73,411.59 | 01.04.02 | 000000000000219 |  |  |  |  |
| 26 | 1.4.2.1 | EXCAVACION EN TERRENO NATURAL CON EQUIPO | manual | 4d | 2025-05-16 | 2025-05-22 |  | as late as possible | CAPATAZ [46.6%]; PEON [93.2%]; EXCAVADORA CAT 336 [110.2%]; TRACTOR DE ORUGAS CAT D6D [46.6%] | 94.92h | 21,682.19 | 01.04.02.01 | 000000000000220 | 2983.05 | 7.27 | 21686.77 | 800 |
| 27 | 1.4.2.2 | EXCAVACION DE UÑA CON EQUIPO | manual | 1d | 2025-05-16 | 2025-05-17 |  | as late as possible | CAPATAZ [8.9%]; PEON [44%]; MOTOBOMBA 8" (34HP) [44%]; EXCAVADORA CAT 336 [49.4%] | 11.69h | 2,093.75 | 01.04.02.02 | 000000000000221 | 237.6 | 8.82 | 2095.63 | 540 |
| 28 | 1.4.2.3 | PERFILADO Y COMPACTACION EN ZONA DE CORTE | manual | 2d | 2025-05-16 | 2025-05-19 |  | as late as possible | CAPATAZ [18.1%]; PEON [90.4%]; EXCAVADORA CAT 336 [45.6%] | 24.66h | 3,445.16 | 01.04.02.03 | 000000000000222 | 1157.7 | 2.99 | 3461.52 | 640 |
| 29 | 1.4.2.4 | PEDRAPLEN e=60 cm | manual | 1d | 2025-05-16 | 2025-05-17 |  | as late as possible | CAPATAZ [10.8%]; OFICIAL [53.4%]; PEON [53.4%]; EXCAVADORA CAT 336 [5.2%]; TRACTOR DE ORUGAS CAT D6D [53.4%] | 14.1h | 2,074.29 | 01.04.02.04 | 000000000000223 | 298.8 | 6.97 | 2082.64 | 560 |
| 30 | 1.4.2.5 | PEDRAPLEN e=30 cm | manual | 1d | 2025-05-16 | 2025-05-17 |  | as late as possible | CAPATAZ [6.3%]; OFICIAL [32.1%]; PEON [32.1%]; EXCAVADORA CAT 336 [3.3%]; TRACTOR DE ORUGAS CAT D6D [32.1%] | 8.46h | 1,248.89 | 01.04.02.05 | 000000000000224 | 153.6 | 8.17 | 1254.91 | 480 |
| 31 | 1.4.2.6 | CONFORMACION DE CUERPO DE DIQUE CON MATERIAL DE PRESTAMO | manual | 2d | 2025-05-16 | 2025-05-19 |  | as late as possible | CAPATAZ [14.6%]; OFICIAL [74%]; PEON [84.7%]; TRACTOR SOBRE ORUGAS CAT D6D [74%]; RODILLO LISO VIBRATORIO AUTOPROPULSADO 101-135HP 10-12TN [74%]; MOTONIVELADORA 140K [37%]; CAMION CISTERNA 5 000 GLN [43%] | 64.2h | 11,001.45 | 01.04.02.06 | 000000000000225 | 650.4 | 16.95 | 11024.28 | 440 |
| 32 | 1.4.2.7 | CONFORMACION DE MATERIAL GRANULAR EN CORONA DE DIQUE | manual | 1d | 2025-05-16 | 2025-05-17 |  | as late as possible | CAPATAZ [5.9%]; OFICIAL [29.5%]; PEON [31.8%]; RODILLO LISO VIBRATORIO AUTOPROPULSADO 101-135HP 10-12TN [29.5%]; MOTONIVELADORA 140K [29.5%]; CAMION CISTERNA 5 000 GLN [9.4%] | 10.84h | 1,487.27 | 01.04.02.07 | 000000000000226 | 70.8 | 21.06 | 1491.05 | 240 |
| 33 | 1.4.2.8 | GEOTEXTIL NO TEJIDO 400 G/M2, INC. COLOCACION | manual | 2d | 2025-05-16 | 2025-05-19 |  | as late as possible | CAPATAZ [13.8%]; OFICIAL [140.9%]; PEON [564.6%]; CAMION GRUA 20 TON [21.2%]; GEOTEXTIL NO TEJIDO DE 400 GR/CM2 [189827%] | 118.47h | 19,254.45 | 01.04.02.08 | 000000000000227 | 1694.88 | 11.88 | 20135.17 | 1200 |
| 34 | 1.4.2.9 | COLOCACION Y ACOMODO DE ROCA EN UÑA DE DIQUE | manual | 1d | 2025-05-16 | 2025-05-17 |  | as late as possible | CAPATAZ [38%]; OFICIAL [76%]; PEON [380.8%]; EXCAVADORA CAT 336 [76%]; TRACTOR SOBRE ORUGAS CAT D6D [19%] | 47.19h | 4,029.88 | 01.04.02.09 | 000000000000119 | 237.6 | 17.07 | 4055.83 | 312 |
| 35 | 1.4.2.10 | COLOCACION Y ACOMODO DE ROCA EN TALUD DE DIQUE | manual | 1d | 2025-05-16 | 2025-05-17 |  | as late as possible | CAPATAZ [36.2%]; OFICIAL [72.3%]; PEON [434%]; EXCAVADORA CAT 336 [144.6%]; TRACTOR SOBRE ORUGAS CAT D6D [18%] | 56.41h | 6,352.15 | 01.04.02.10 | 000000000000228 | 162 | 39.4 | 6382.8 | 224 |
| 36 | 1.4.2.11 | CONFORMACION DE RELLENO NO ESTRUCTURAL CON MATERIAL PROPIO | manual | 1d | 2025-05-16 | 2025-05-17 |  | as late as possible | CAPATAZ [10.3%]; OFICIAL [20.3%]; PEON [20.3%]; TRACTOR SOBRE ORUGAS CAT D6D [20.3%] | 5.7h | 742.13 | 01.04.02.11 | 000000000000229 | 171.15 | 4.35 | 744.5 | 840 |
| 37 | 1.4.3 | **DIQUE DE TIERRA COMPACTADA A1-D-02** |  | 4d | 2025-05-16 | 2025-05-22 | 0d |  |  | 573.83h | 91,695.04 | 01.04.03 | 000000000000230 |  |  |  |  |
| 38 | 1.4.3.1 | EXCAVACION EN TERRENO NATURAL CON EQUIPO | manual | 4d | 2025-05-16 | 2025-05-22 |  | as late as possible | CAPATAZ [48.6%]; PEON [97.2%]; EXCAVADORA CAT 336 [114.9%]; TRACTOR DE ORUGAS CAT D6D [48.6%] | 99.01h | 22,615.16 | 01.04.03.01 | 000000000000231 | 3111.41 | 7.27 | 22619.95 | 800 |
| 39 | 1.4.3.2 | EXCAVACION DE UÑA CON EQUIPO | manual | 1d | 2025-05-16 | 2025-05-17 |  | as late as possible | CAPATAZ [8.9%]; PEON [43.7%]; MOTOBOMBA 8" (34HP) [43.7%]; EXCAVADORA CAT 336 [49%] | 11.62h | 2,080.23 | 01.04.03.02 | 000000000000232 | 236.07 | 8.82 | 2082.14 | 540 |
| 40 | 1.4.3.3 | PERFILADO Y COMPACTACION EN ZONA DE CORTE | manual | 3d | 2025-05-16 | 2025-05-20 |  | as late as possible | CAPATAZ [15.3%]; PEON [76.4%]; EXCAVADORA CAT 336 [38.5%] | 31.25h | 4,366.63 | 01.04.03.03 | 000000000000233 | 1467.35 | 2.99 | 4387.38 | 640 |
| 41 | 1.4.3.4 | PEDRAPLEN e=60 cm | manual | 1d | 2025-05-16 | 2025-05-17 |  | as late as possible | CAPATAZ [12.3%]; OFICIAL [60.7%]; PEON [60.7%]; EXCAVADORA CAT 336 [5.9%]; TRACTOR DE ORUGAS CAT D6D [60.7%] | 16.04h | 2,359.18 | 01.04.03.04 | 000000000000234 | 339.83 | 6.97 | 2368.62 | 560 |
| 42 | 1.4.3.5 | PEDRAPLEN e=30 cm | manual | 1d | 2025-05-16 | 2025-05-17 |  | as late as possible | CAPATAZ [7.2%]; OFICIAL [36.3%]; PEON [36.3%]; EXCAVADORA CAT 336 [3.7%]; TRACTOR DE ORUGAS CAT D6D [36.3%] | 9.57h | 1,412.26 | 01.04.03.05 | 000000000000235 | 173.69 | 8.17 | 1419.05 | 480 |
| 43 | 1.4.3.6 | CONFORMACION DE CUERPO DE DIQUE CON MATERIAL DE PRESTAMO | manual | 3d | 2025-05-16 | 2025-05-20 |  | as late as possible | CAPATAZ [18.5%]; OFICIAL [93.7%]; PEON [107.3%]; TRACTOR SOBRE ORUGAS CAT D6D [93.7%]; RODILLO LISO VIBRATORIO AUTOPROPULSADO 101-135HP 10-12TN [93.7%]; MOTONIVELADORA 140K [46.9%]; CAMION CISTERNA 5 000 GLN [54.4%] | 121.98h | 20,902.63 | 01.04.03.06 | 000000000000236 | 1235.75 | 16.95 | 20945.96 | 440 |
| 44 | 1.4.3.7 | CONFORMACION DE MATERIAL GRANULAR EN CORONA DE DIQUE | manual | 1d | 2025-05-16 | 2025-05-17 |  | as late as possible | CAPATAZ [4.8%]; OFICIAL [23.6%]; PEON [25.5%]; RODILLO LISO VIBRATORIO AUTOPROPULSADO 101-135HP 10-12TN [23.6%]; MOTONIVELADORA 140K [23.6%]; CAMION CISTERNA 5 000 GLN [7.5%] | 8.69h | 1,192.35 | 01.04.03.07 | 000000000000237 | 56.76 | 21.06 | 1195.37 | 240 |
| 45 | 1.4.3.8 | GEOTEXTIL NO TEJIDO 400 G/M2, INC. COLOCACION | manual | 2d | 2025-05-16 | 2025-05-19 |  | as late as possible | CAPATAZ [15.8%]; OFICIAL [161.7%]; PEON [648.1%]; CAMION GRUA 20 TON [24.3%]; GEOTEXTIL NO TEJIDO DE 400 GR/CM2 [217908%] | 136h | 22,102.82 | 01.04.03.08 | 000000000000238 | 1945.61 | 11.88 | 23113.85 | 1200 |
| 46 | 1.4.3.9 | COLOCACION Y ACOMODO DE ROCA EN UÑA DE DIQUE | manual | 1d | 2025-05-16 | 2025-05-17 |  | as late as possible | CAPATAZ [38.7%]; OFICIAL [77.3%]; PEON [387.2%]; EXCAVADORA CAT 336 [77.3%]; TRACTOR SOBRE ORUGAS CAT D6D [19.3%] | 47.99h | 4,098.08 | 01.04.03.09 | 000000000000239 | 241.62 | 17.07 | 4124.45 | 312 |
| 47 | 1.4.3.10 | COLOCACION Y ACOMODO DE ROCA EN TALUD DE DIQUE | manual | 1d | 2025-05-16 | 2025-05-17 |  | as late as possible | CAPATAZ [50.1%]; OFICIAL; PEON [599.3%]; EXCAVADORA CAT 336 [199.7%]; TRACTOR SOBRE ORUGAS CAT D6D [24.9%] | 77.91h | 8,772.16 | 01.04.03.10 | 000000000000240 | 223.71 | 39.4 | 8814.17 | 224 |
| 48 | 1.4.3.11 | CONFORMACION DE RELLENO NO ESTRUCTURAL CON MATERIAL PROPIO | manual | 1d | 2025-05-16 | 2025-05-17 |  | as late as possible | CAPATAZ [24.8%]; OFICIAL [49.1%]; PEON [49.1%]; TRACTOR SOBRE ORUGAS CAT D6D [49.1%] | 13.77h | 1,793.54 | 01.04.03.11 | 000000000000241 | 413.62 | 4.35 | 1799.25 | 840 |

| ID | WBS | Task | Type | Duration | Start | Finish | Total slack | Constraint | Resources | Work | Cost | Text1 | Text8 | Text2 | Text3 | Text4 | Text6 |
| --- | --- | --- | --- | --- | --- | --- | --- | --- | --- | --- | --- | --- | --- | --- | --- | --- | --- |
| 49 | 1.4.4 | **DIQUE DE TIERRA COMPACTADA A1-I-02** |  | 6d | 2025-05-16 | 2025-05-25 | 0d |  |  | 656.75h | 107,369.55 | 01.04.04 | 000000000000242 |  |  |  |  |
| 50 | 1.4.4.1 | EXCAVACION EN TERRENO NATURAL CON EQUIPO | manual | 6d | 2025-05-16 | 2025-05-25 |  | as late as possible | CAPATAZ [46.1%]; PEON [92.2%]; EXCAVADORA CAT 336 [109%]; TRACTOR DE ORUGAS CAT D6D [46.1%] | 140.86h | 32,175.25 | 01.04.04.01 | 000000000000243 | 4426.7 | 7.27 | 32182.11 | 800 |
| 51 | 1.4.4.2 | EXCAVACION DE UÑA CON EQUIPO | manual | 1d | 2025-05-16 | 2025-05-17 |  | as late as possible | CAPATAZ [9.7%]; PEON [47.9%]; MOTOBOMBA 8" (34HP) [47.9%]; EXCAVADORA CAT 336 [53.8%] | 12.75h | 2,282.13 | 01.04.04.02 | 000000000000244 | 258.98 | 8.82 | 2284.2 | 540 |
| 52 | 1.4.4.3 | PERFILADO Y COMPACTACION EN ZONA DE CORTE | manual | 3d | 2025-05-16 | 2025-05-20 |  | as late as possible | CAPATAZ [15.6%]; PEON [77.9%]; EXCAVADORA CAT 336 [39.2%] | 31.85h | 4,449.43 | 01.04.04.03 | 000000000000245 | 1495.17 | 2.99 | 4470.56 | 640 |
| 53 | 1.4.4.4 | PEDRAPLEN e=60 cm | manual | 2d | 2025-05-16 | 2025-05-19 |  | as late as possible | CAPATAZ [10.8%]; OFICIAL [53.4%]; PEON [53.4%]; EXCAVADORA CAT 336 [5.2%]; TRACTOR DE ORUGAS CAT D6D [53.4%] | 28.22h | 4,149.99 | 01.04.04.04 | 000000000000246 | 597.8 | 6.97 | 4166.67 | 560 |
| 54 | 1.4.4.5 | PEDRAPLEN e=30 cm | manual | 1d | 2025-05-16 | 2025-05-17 |  | as late as possible | CAPATAZ [7.8%]; OFICIAL [39.6%]; PEON [39.6%]; EXCAVADORA CAT 336 [4%]; TRACTOR DE ORUGAS CAT D6D [39.6%] | 10.45h | 1,541.61 | 01.04.04.05 | 000000000000247 | 189.6 | 8.17 | 1549.03 | 480 |
| 55 | 1.4.4.6 | CONFORMACION DE CUERPO DE DIQUE CON MATERIAL DE PRESTAMO | manual | 3d | 2025-05-16 | 2025-05-20 |  | as late as possible | CAPATAZ [19.4%]; OFICIAL [97.9%]; PEON [112.2%]; TRACTOR SOBRE ORUGAS CAT D6D [97.9%]; RODILLO LISO VIBRATORIO AUTOPROPULSADO 101-135HP 10-12TN [97.9%]; MOTONIVELADORA 140K [49%]; CAMION CISTERNA 5 000 GLN [56.9%] | 127.49h | 21,847.47 | 01.04.04.06 | 000000000000248 | 1291.61 | 16.95 | 21892.79 | 440 |
| 56 | 1.4.4.7 | CONFORMACION DE MATERIAL GRANULAR EN CORONA DE DIQUE | manual | 1d | 2025-05-16 | 2025-05-17 |  | as late as possible | CAPATAZ [4.3%]; OFICIAL [21.3%]; PEON [23%]; RODILLO LISO VIBRATORIO AUTOPROPULSADO 101-135HP 10-12TN [21.3%]; MOTONIVELADORA 140K [21.3%]; CAMION CISTERNA 5 000 GLN [6.8%] | 7.83h | 1,074.05 | 01.04.04.07 | 000000000000249 | 51.13 | 21.06 | 1076.8 | 240 |
| 57 | 1.4.4.8 | GEOTEXTIL NO TEJIDO 400 G/M2, INC. COLOCACION | manual | 2d | 2025-05-16 | 2025-05-19 |  | as late as possible | CAPATAZ [17.4%]; OFICIAL [178.1%]; PEON [713.6%]; CAMION GRUA 20 TON [26.8%]; GEOTEXTIL NO TEJIDO DE 400 GR/CM2 [239922%] | 149.74h | 24,335.7 | 01.04.04.08 | 000000000000250 | 2142.16 | 11.88 | 25448.86 | 1200 |
| 58 | 1.4.4.9 | COLOCACION Y ACOMODO DE ROCA EN UÑA DE DIQUE | manual | 1d | 2025-05-16 | 2025-05-17 |  | as late as possible | CAPATAZ [41.4%]; OFICIAL [82.9%]; PEON [415%]; EXCAVADORA CAT 336 [82.9%]; TRACTOR SOBRE ORUGAS CAT D6D [20.7%] | 51.43h | 4,392.51 | 01.04.04.09 | 000000000000251 | 258.98 | 17.07 | 4420.79 | 312 |
| 59 | 1.4.4.10 | COLOCACION Y ACOMODO DE ROCA EN TALUD DE DIQUE | manual | 2d | 2025-05-16 | 2025-05-19 |  | as late as possible | CAPATAZ [25.5%]; OFICIAL [50.9%]; PEON [305.5%]; EXCAVADORA CAT 336 [101.8%]; TRACTOR SOBRE ORUGAS CAT D6D [12.7%] | 79.41h | 8,942.41 | 01.04.04.10 | 000000000000252 | 228.06 | 39.4 | 8985.56 | 224 |
| 60 | 1.4.4.11 | CONFORMACION DE RELLENO NO ESTRUCTURAL CON MATERIAL PROPIO | manual | 1d | 2025-05-16 | 2025-05-17 |  | as late as possible | CAPATAZ [30.2%]; OFICIAL [59.7%]; PEON [59.7%]; TRACTOR SOBRE ORUGAS CAT D6D [59.7%] | 16.73h | 2,179.01 | 01.04.04.11 | 000000000000253 | 502.52 | 4.35 | 2185.96 | 840 |
| 61 | 1.5 | **RAMPAS** |  | 1d | 2025-05-16 | 2025-05-17 | 0d |  |  | 5.49h | 880.76 | 01.05 | 000000000000254 |  |  |  |  |
| 62 | 1.5.1 | EXCAVACION EN TERRENO NATURAL CON EQUIPO | manual | 1d | 2025-05-16 | 2025-05-17 |  | as late as possible | CAPATAZ [0.4%]; PEON [0.8%]; EXCAVADORA CAT 336 [0.9%]; TRACTOR DE ORUGAS CAT D6D [0.4%] | 0.2h | 44.73 | 01.05.01 | 000000000000255 | 6.15 | 7.27 | 44.71 | 800 |
| 63 | 1.5.2 | CONFORMACION DE CUERPO DE RAMPA CON MATERIAL DE PRESTAMO | manual | 1d | 2025-05-16 | 2025-05-17 |  | as late as possible | CAPATAZ [0.6%]; OFICIAL [3.2%]; PEON [3.6%]; TRACTOR DE ORUGAS CAT D6D [3.2%]; RODILLO LISO VIBRATORIO AUTOPROPULSADO 101-135HP 10-12TN [3.2%]; CAMION CISTERNA 5 000 GLN [1.5%] | 1.24h | 196.03 | 01.05.02 | 000000000000257 | 11.67 | 16.82 | 196.29 | 360 |
| 64 | 1.5.3 | CONFORMACION DE CORONA DE RAMPA COM MATERIAL DE PRESTAMO | manual | 1d | 2025-05-16 | 2025-05-17 |  | as late as possible | CAPATAZ [2.1%]; OFICIAL [10.4%]; PEON [11.8%]; TRACTOR DE ORUGAS CAT D6D [10.4%]; RODILLO LISO VIBRATORIO AUTOPROPULSADO 101-135HP 10-12TN [10.4%]; CAMION CISTERNA 5 000 GLN [5.5%] | 4.05h | 640.01 | 01.05.03 | 000000000000258 | 41.67 | 15.38 | 640.88 | 400 |
| 65 | 2 | **OBRAS DE ARTE (REBOSES)** |  | 81d | 2025-05-16 | 2025-09-22 | 0d |  |  | 8869.19h | 569,215.65 | 02 | 000000000000259 |  |  |  |  |
| 66 | 2.1 | **ESTRUCTURAS DE REBOSE** |  | 81d | 2025-05-16 | 2025-09-22 | 0d |  |  | 8869.19h | 569,215.65 | 02.01 | 000000000000260 |  |  |  |  |
| 67 | 2.1.1 | **MOVIMIENTO DE TIERRAS** |  | 81d | 2025-05-16 | 2025-09-22 | 0d |  |  | 8079.15h | 464,316.61 | 02.01.01 | 000000000000261 |  |  |  |  |
| 68 | 2.1.1.1 | DESBROCE Y LIMPIEZA DE TERRENO | manual | 81d | 2025-05-16 | 2025-09-22 |  | as late as possible | PEON [996%]; TRACTOR DE ORUGAS DE 190-240 HP; MOTONIVELADORA 130 - 135 HP | 7750.4h | 430,114.03 | 02.01.01.01 | 000000000000265 | 60.51 | 7203.01 | 435854.14 | 0.75 |
| 69 | 2.1.1.2 | EXCAVACION ESTRUCTURAL BAJO AGUA (EXCAVACION ESTRUCTURAL PARA OBRAS DE ARTE) | manual | 5d | 2025-05-16 | 2025-05-24 |  | as late as possible | CAPATAZ [8.3%]; OFICIAL [82.6%]; PEON [165.1%]; EXCAVADORA CAT 336 [82.6%] | 135.4h | 16,013.94 | 02.01.01.02 | 000000000000268 | 412.79 | 38.97 | 16086.43 | 100 |
| 70 | 2.1.1.3 | CAMA DE ARENA h=0.10 | manual | 1d | 2025-05-16 | 2025-05-17 |  | as late as possible | CAPATAZ [6%]; OFICIAL [60.1%]; PEON [60.6%]; CARGADOR FRONTAL CAT 966-H [1%]; COMPACTADORA VIBRATORIA TIPO PLANCHA 7 HP [30.1%]; CAMION CISTERNA 5 000 GLN [1.9%]; CAMION VOLQUETE DE 15 m3 [31.6%]; ARENA GRUESA [1731.6%] | 15.31h | 1,554.21 | 02.01.01.03 | 000000000000266 | 14.43 | 108.52 | 1565.94 | 48 |
| 71 | 2.1.1.4 | RELLENO ESTRUCTURAL PARA OBRAS DE ARTE, CON MATERIAL PROPIO | manual | 6d | 2025-05-16 | 2025-05-25 |  | as late as possible | CAPATAZ [8.3%]; OPERARIO [83.5%]; PEON [85%]; COMPACTADORA VIBRATORIA TIPO PLANCHA 7 HP [83.5%]; RODILLO LISO VIBRATORIO MANUAL 10.8 HP 0.8-1.1 Ton [83.5%]; RETROEXCAVADORA SOBRE LLANTAS 94 HP 1.25 Y3 [20.9%]; CAMION CISTERNA 5 000 GLN [6.1%]; MATERIAL PROPIO DE LAS EXCAVACIONES [31689.4%] | 178.04h | 16,634.44 | 02.01.01.04 | 000000000000267 | 275.56 | 60.61 | 16701.69 | 55 |
| 72 | 2.1.2 | **OBRAS DE CONCRETO** |  | 16d | 2025-05-16 | 2025-06-10 | 0d |  |  | 721h | 68,768.76 | 02.01.02 | 000000000000262 |  |  |  |  |
| 73 | 2.1.2.1 | CONCRETO f´c = 100 kg/cm2 | manual | 1d | 2025-05-16 | 2025-05-17 |  | as late as possible | CAPATAZ [6.8%]; OFICIAL [27.4%]; PEON [109.5%]; CONCRETO PREMEZCLADO F'C=100 kg/cm2 CON CEMENTO T-V [459.9%] | 11.5h | 2,664.54 | 02.01.02.01 | 000000000000269 | 4.38 | 610.12 | 2672.33 | 16 |
| 74 | 2.1.2.2 | CONCRETO f´c = 280 kg/cm2 | manual | 3d | 2025-05-16 | 2025-05-20 |  | as late as possible | CAPATAZ [15%]; OPERARIO [75%]; OFICIAL [75%]; PEON [299.8%]; VIBRADORA DE CONCRETO 4HP 1.50" [75%]; CONCRETO PREMEZCLADO F'C=280 kg/cm2 CON CEMENTO T-V [3777.9%] | 129.53h | 29,995.3 | 02.01.02.02 | 000000000000270 | 35.98 | 835.87 | 30074.6 | 16 |
| 75 | 2.1.2.3 | ENCOFRADO Y DESENCOFRADO RECTO | manual | 16d | 2025-05-16 | 2025-06-10 |  | as late as possible | DESMOLDADOR PARA ENCOFRADO [947%]; CAPATAZ [9.9%]; OPERARIO [98.7%]; OFICIAL [98.7%]; PEON [49.3%]; CAMION GRUA 20 TON [4.9%]; ALAMBRE NEGRO #8 [1894.1%]; CLAVOS DIFERENTES MEDIDAS [3788.2%]; MADERA TORNILLO [85234.5%] | 334.63h | 16,563.28 | 02.01.02.03 | 000000000000271 | 189.41 | 88.79 | 16817.71 | 12 |
| 76 | 2.1.2.4 | ACERO DE REFUERZO fy=4200 Kg/cm2. | manual | 12d | 2025-05-16 | 2025-06-04 |  | as late as possible | CAPATAZ [9.8%]; OPERARIO [98.3%]; OFICIAL [98.3%]; PEON [49.1%]; ALAMBRE NEGRO N° 16 [14744.3%]; ACERO CORRUGADO fy = 4200 kg/cm2 GRADO 60 [309630%] | 245.35h | 19,545.64 | 02.01.02.04 | 000000000000272 | 2948.86 | 6.7 | 19757.36 | 250 |

| ID | WBS | Task | Type | Duration | Start | Finish | Predecessors | Total slack | Constraint | Resources | Work | Cost | Text1 | Text8 | Text2 | Text3 | Text4 | Text6 |
| --- | --- | --- | --- | --- | --- | --- | --- | --- | --- | --- | --- | --- | --- | --- | --- | --- | --- | --- |
| 77 | 2.1.3 | **TUBERIA** |  | 2d | 2025-05-16 | 2025-05-19 |  | 0d |  |  | 69.04h | 36,130.29 | 02.01.03 | 000000000000263 |  |  |  |  |
| 78 | 2.1.3.1 | SUMINISTRO E INSTALACION DE TUBERIA HDPE DN800 mm | manual | 2d | 2025-05-16 | 2025-05-19 |  |  | as late as possible | CAPATAZ [66.4%]; OPERARIO [66.4%]; OFICIAL [132.8%]; PEON [132.8%]; EXCAVADORA CAT 336 [33.2%]; TUBERIA HDPE DN 800mm [2509.5%] | 69.04h | 36,130.29 | 02.01.03.01 | 000000000000273 | 23.9 | 1515.25 | 36214.48 | 18 |
| 79 | 3 | **TRASPORTE DE MATERIAL** |  | 353d | 2025-05-16 | 2026-12-01 |  | 0d |  |  | 9564.29h | 1,987,342.5 | 03 | 000000000000264 |  |  |  |  |
| 80 | 3.1 | TRANSPORTE DE MATERIAL GRANULAR PARA DISTANCIAS <1KM | manual | 43d | 2025-05-16 | 2025-07-23 |  |  | as late as possible | PEON - VIGIA [19.6%]; CAMION VOLQUETE DE 15 m3 [97.8%] | 403.53h | 64,598.99 | 03.01 | 000000000000274 | 11025.39 | 5.86 | 64608.79 | 262.5 |
| 81 | 3.2 | TRANSPORTE DE MATERIAL GRANULAR PARA DISTANCIAS >1KM | manual | 353d | 2025-05-16 | 2026-12-01 |  |  | as late as possible | CAMION VOLQUETE DE 15 m3 | 2824h | 530,431.92 | 03.02 | 000000000000275 | 224969.4 | 2.35 | 528678.09 | 637.5 |
| 82 | 3.3 | TRANSPORTE DE ROCA PARAR DISTANCIAS <1KM | manual | 11d | 2025-05-16 | 2025-06-02 |  |  | as late as possible | PEON - VIGIA [18.7%]; CAMION VOLQUETE 22M3 [93.7%]; EXCAVADORA CAT 336 [45.9%] | 139.4h | 36,572.99 | 03.03 | 000000000000276 | 3234.35 | 11.31 | 36580.5 | 314.2857 |
| 83 | 3.4 | TRANSPORTE DE ROCA PARAR DISTANCIAS >1KM | manual | 52d | 2025-05-16 | 2025-08-07 |  |  | as late as possible | CAMION VOLQUETE 22M3 | 416h | 98,583.68 | 03.04 | 000000000000277 | 41401.42 | 2.37 | 98121.37 | 801.4286 |
| 84 | 3.5 | TRANSPORTE DE MATERIAL EXCEDENTE PARA DISTANCIAS <1KM | manual | 1d | 2025-05-16 | 2025-05-17 |  |  | as late as possible | CAMION VOLQUETE 22M3 [1911.2%]; CAMION VOLQUETE DE 15 m3 [2777.9%] | 375.12h | 77,973.96 | 03.05 | 000000000000278 | 35556.62 | 2.2 | 78224.56 |  |
| 85 | 3.6 | TRANSPORTE DE MATERIAL EXCEDENTE PARA DISTANCIAS >1KM | manual | 1d | 2025-05-16 | 2025-05-17 |  |  | as late as possible | CAMION VOLQUETE 22M3 [41639.7%]; CAMION VOLQUETE DE 15 m3 [25938.3%] | 5406.24h | 1,179,180.97 | 03.06 | 000000000000279 | 553350.95 | 2.14 | 1184171.03 | 637.5 |
| 86 | 4 | **PROGRAMA DE CIERRE DE OBRA** |  | 24d | 2025-05-16 | 2025-06-23 |  | 0d |  |  | 400.31h | 119,917.25 | 04 | 000000000000280 |  |  |  |  |
| 87 | 4.1 | ACONDICIONAMIENTO DE DEPOSITOS DE MATERIALES EXCEDENTES (DME | manual | 24d | 2025-05-16 | 2025-06-23 |  |  | as late as possible | PEON - VIGIA [96.6%]; TRACTOR SOBRE ORUGAS CAT D8T [96.6%]; EXCAVADORA CAT 336 [15.4%] | 400.31h | 119,917.25 | 04.01 | 000000000000282 | 42138 | 2.84 | 119671.92 | 1800 |
| 88 | 5 | **SEGURIDAD Y SALUD OCUPACIONAL** |  | 1d | 2025-05-25 | 2025-05-27 |  | 0d |  |  | 79h | 467,966.35 | 05 | 000000000000281 |  |  |  |  |
| 89 | 5.1 | SEGURIDAD Y SALUD OCUPACIONAL | manual | 1d | 2025-05-25 | 2025-05-27 | 3 |  | as late as possible | ELABORACION IMPLEMENTACION Y ADMINITRACION DEL PLAN DE SEGURIDAD Y SALUD EN EL TRABAJO [50%]; EQUIPO DE PREVENCION DE FATIGA SOMNOLENCIA [50%]; EQUIPO DE PROTECCION COLECTIVA [50%]; CAPACITACION EN SEGURIDAD Y SALUD [50%]; BAÑOS PORTATILES [493.8%]; LAVAMANOS PORTATILES [493.8%]; SEÑALIZACION TEMPORAL DE SEGURIDAD [50%]; CHARLAS DE INDUCCION [13800%]; EPPS PERSONAL INDIRECTO [3750%]; EPPS PERSONAL DIRECTO [10050%]; RECURSOS PARA RESPUESTAS ANTE EMERGENCIAS DE SEGURIDAD Y SALUD EN EL TRABAJO [50%]; EXAMEN MEDICO-INGRESO [13800%]; EXAMEN MEDICO-SALIDA [13800%] | 79h | 467,966.35 | 05.01 | 000000000000283 | 0.5 | 935932.71 | 467966.36 |  |
